# Standaard planning MS Project Team Projecten

Schedule from MS Project, 2020-12-22 to 2024-02-08.

## Calendars

- Standaard: Mon-Fri 08:00-12:00, 13:00-17:00; Sat-Sun off.

## Schedule

| ID | WBS | Task | Duration | Start | Finish | Predecessors | Total slack | Constraint |
| --- | --- | --- | --- | --- | --- | --- | --- | --- |
| 1 | 1 | **Standaard planning team Projecten** | 809d | 2021-01-04 | 2024-02-08 |  | 0d |  |
| 2 | 1.1 | **Initiatieffase** | 17d | 2021-01-04 | 2021-01-26 |  | 0d |  |
| 3 | 1.1.1 | Ontvangen projectopdracht | 1d | 2021-01-04 | 2021-01-04 |  | 0d | start no earlier than 2021-01-04 |
| 4 | 1.1.2 | Project Start Up | 1d | 2021-01-26 | 2021-01-26 | 3FS+3w | 0d |  |
| 5 | 1.2 | **Definitiefase** | 11d | 2021-01-27 | 2021-02-10 |  | 0d |  |
| 6 | 1.2.1 | Opstellen projectplan | 2w | 2021-01-27 | 2021-02-09 | 4 | 0d |  |
| 7 | 1.2.2 | Goedkeuring projectplan | 1d | 2021-02-10 | 2021-02-10 | 6 | 0d |  |
| 8 | 1.3 | **Uitvoeringsfase** | 660d | 2021-02-11 | 2023-08-23 |  | 0d |  |
| 9 | 1.3.1 | Aanbesteding voorbereiding | 2mo | 2021-02-11 | 2021-04-07 | 7 | 0d |  |
| 10 | 1.3.2 | Inventarisatie en voorbereiding | 4mo | 2021-04-08 | 2021-07-28 | 9 | 0d |  |
| 11 | 1.3.3 | Opstellen programma van eisen (PVE) | 2w | 2021-07-29 | 2021-08-11 | 10 | 0d |  |
| 12 | 1.3.4 | Toetsronde PVE | 3w | 2021-08-12 | 2021-09-01 | 11 | 0d |  |
| 13 | 1.3.5 | Opstellen schetsontwerp (SO) | 4w | 2021-09-02 | 2021-09-29 | 12 | 0d |  |
| 14 | 1.3.6 | Toetsronde SO | 3w | 2021-09-30 | 2021-10-20 | 13 | 0d |  |
| 15 | 1.3.7 | Opstellen voorlopig ontwerp (VO) | 6w | 2021-10-21 | 2021-12-01 | 14 | 0d |  |
| 16 | 1.3.8 | Toetsronde VO | 3w | 2021-12-02 | 2021-12-22 | 15 | 0d |  |
| 17 | 1.3.9 | Opstellen definitief ontwerp (DO) | 5w | 2021-12-23 | 2022-01-26 | 16 | 0d |  |
| 18 | 1.3.10 | Toetsronde DO | 3w | 2022-01-27 | 2022-02-16 | 17 | 0d |  |
| 19 | 1.3.11 | Opstellen bestek | 4w | 2022-02-17 | 2022-03-16 | 18 | 0d |  |
| 20 | 1.3.12 | Toetsronde bestek | 3w | 2022-03-17 | 2022-04-06 | 19 | 0d |  |
| 21 | 1.3.13 | Aanbesteding uitvoering | 3mo | 2022-04-07 | 2022-06-29 | 20 | 0d |  |
| 22 | 1.3.14 | Uitvoering | 15mo | 2022-06-30 | 2023-08-23 | 21 | 0d |  |
| 23 | 1.4 | **Afrondingsfase** | 121d | 2023-08-24 | 2024-02-08 |  | 0d |  |
| 24 | 1.4.1 | Overdracht naar opdrachtgever | 1d | 2023-08-24 | 2023-08-24 | 22 | 0d |  |
| 25 | 1.4.2 | Evaluatie project | 1d | 2023-08-25 | 2023-08-25 | 24 | 119d |  |
| 26 | 1.4.3 | Nazorg | 6mo | 2023-08-25 | 2024-02-08 | 24 | 0d |  |

| ID | WBS | Task | Type | Duration | Start | Finish | Total slack |
| --- | --- | --- | --- | --- | --- | --- | --- |
| 29 | 2 | **Mijlpalen** |  | 1d | 2020-12-22 | 2020-12-22 | 0d |
| 30 | 2.1 | Goedkeuring projectplan | manual | 1d | 2020-12-22 | 2020-12-22 |  |
| 31 | 2.2 | Toetsronde PVE | manual | 1d | 2020-12-22 | 2020-12-22 |  |
| 32 | 2.3 | Toetsronde SO | manual | 1d | 2020-12-22 | 2020-12-22 |  |
| 33 | 2.4 | Toetsronde VO | manual | 1d | 2020-12-22 | 2020-12-22 |  |
| 34 | 2.5 | Toetsronde DO | manual | 1d | 2020-12-22 | 2020-12-22 |  |
| 35 | 2.6 | Toetsronde bestek | manual | 1d | 2020-12-22 | 2020-12-22 |  |
| 36 | 2.7 | Overdracht naar opdrachtgever | manual | 1d | 2020-12-22 | 2020-12-22 |  |
